# REGNET02

Schedule from MS Project, 2001-10-01 to 2002-04-01.
Cultural Heritage & E-Commerce
AIT

## Calendars

- Standard: Mon-Fri 08:00-12:00, 13:00-17:00; Sat-Sun off. Exceptions (off unless hours are given): 2002-03-30 08:00-12:00, 13:00-17:00.

## Schedule

| ID | WBS | Task | Duration | Start | Finish | Baseline start | Baseline finish | Baseline duration | Total slack | Constraint |
| --- | --- | --- | --- | --- | --- | --- | --- | --- | --- | --- |
| 1 | 1 | **WP-2 Implementation of the System and Preparation of Services and Product Generation** | 131d? | 2001-10-01 | 2002-03-30 | 2001-01-01 | 2001-06-29 | 130d | 1d |  |
| 2 | 1.1 | **T2.1 Preparation of Content and Products** | 130d? | 2001-10-01 | 2002-03-29 | 2001-01-01 | 2001-06-29 | 130d | 2d |  |
| 3 | 1.1.1 | T2.1.1 Cataloguing & Digitising | 130d? | 2001-10-01 | 2002-03-29 |  |  |  | 2d | start no earlier than 2001-10-01 |
| 4 | 1.1.2 | T2.1.2 Thematic Content | 130d? | 2001-10-01 | 2002-03-29 |  |  |  | 2d | start no earlier than 2001-10-01 |
| 5 | 1.2 | **T2.2 System Implementation (Version 1)** | 131d? | 2001-10-01 | 2002-03-30 | 2001-01-01 | 2001-01-01 | 1d | 1d |  |
| 6 | 1.3 | **T2.2.1 - Node-1: Portal** | 131d? | 2001-10-01 | 2002-03-30 | 2001-01-01 | 2001-01-01 | 1d | 1d |  |
| 7 | 1.2.1.1 | T2.2.1.1 - Node-1: ~ Data Generation | 131d? | 2001-10-01 | 2002-03-30 |  |  |  | 1d | start no earlier than 2001-10-01 |
| 8 | 1.2.1.2 | T2.2.1.2 - Node-1: ~ Search System | 131d? | 2001-10-01 | 2002-03-30 |  |  |  | 1d | start no earlier than 2001-10-01 |
| 9 | 1.2.1.3 | T2.2.1.3 - Node-1: ~ e-Business | 131d? | 2001-10-01 | 2002-03-30 |  |  |  | 1d | start no earlier than 2001-10-01 |
| 10 | 1.2.2 | **T2.2.2 - Node-2: CH-Data Management** | 131d? | 2001-10-01 | 2002-03-30 |  |  |  | 1d |  |
| 11 | 1.2.2.1 | T2.2.2.1 - Node-2: ~ Repository Management | 131d? | 2001-10-01 | 2002-03-30 |  |  |  | 1d | start no earlier than 2001-10-01 |
| 12 | 1.2.2.2 | T2.2.2.2 - Node-2: ~ Reference System | 131d? | 2001-10-01 | 2002-03-30 |  |  |  | 1d | start no earlier than 2001-10-01 |
| 13 | 1.2.3 | **T2.2.3 - Node-3: e-Business-Data Management** | 131d? | 2001-10-01 | 2002-03-30 |  |  |  | 1d |  |
| 14 | 1.2.3.1 | T2.2.3.1 - Node-3: ~ Catalogue Management | 131d? | 2001-10-01 | 2002-03-30 |  |  |  | 1d | start no earlier than 2001-10-01 |
| 15 | 1.2.3.2 | T2.2.3.2 - Node-3: ~ Procurement & Delivery | 131d? | 2001-10-01 | 2002-03-30 |  |  |  | 1d | start no earlier than 2001-10-01 |
| 16 | 1.2.4 | **T2.2.4 - Node-4: Ontology Checker** | 131d? | 2001-10-01 | 2002-03-30 |  |  |  | 1d |  |
| 17 | 1.2.4.1 | T2.2.4.1 - Node-4: ~ Knowledge Base | 131d? | 2001-10-01 | 2002-03-30 |  |  |  | 1d | start no earlier than 2001-10-01 |
| 18 | 1.2.5 | **T2.2.5 - Node-5: Electronic Publisher** | 131d? | 2001-10-01 | 2002-03-30 |  |  |  | 1d |  |
| 19 | 1.2.5.1 | T2.2.5.1 - Node-5: ~ Electronic Publisher | 131d? | 2001-10-01 | 2002-03-30 |  |  |  | 1d | finish no earlier than 2002-03-30 |
| 20 | 1.2.6 | **T2.2.6 - Core System** | 131d? | 2001-10-01 | 2002-03-30 |  |  |  | 1d |  |
| 21 | 1.2.6.1 | T2.2.6.1 - Core System: ~ Architecture | 131d? | 2001-10-01 | 2002-03-30 |  |  |  | 1d | start no earlier than 2001-10-01 |
| 22 | 1.2.6.2 | T2.2.6.2 - Core System: ~ Interfaces | 131d? | 2001-10-01 | 2002-03-30 |  |  |  | 1d | start no earlier than 2001-10-01 |
| 23 | 1.2.6.3 | T2.2.6.3 - Core System: ~ Platform | 131d? | 2001-10-01 | 2002-03-30 |  |  |  | 1d |  |
| 24 | 1.2.7 | **T2.2.7 - Prototype Management** | 131d? | 2001-10-01 | 2002-03-30 |  |  |  | 1d |  |
| 25 | 1.2.7.1 | T2.2.7.1 - Prototype sites | 131d? | 2001-10-01 | 2002-03-30 |  |  |  | 1d | finish no earlier than 2002-03-30 |
| 26 | 1.2.7.2 | T2.2.7.2 - Deployment | 131d? | 2001-10-01 | 2002-03-30 |  |  |  | 1d | finish no earlier than 2002-03-30 |
| 27 | 1.2.7.3 | T2.2.7.3 - Population of Database | 131d? | 2001-10-01 | 2002-03-30 |  |  |  | 1d | finish no earlier than 2002-03-30 |
| 28 | 1.3 | T2.3 Setup of the Legal Framework | 131d? | 2001-10-01 | 2002-03-30 |  |  |  | 1d |  |

| ID | WBS | Task | Type | Duration | Start | Finish | Baseline start | Baseline finish | Baseline duration | Total slack | Constraint |
| --- | --- | --- | --- | --- | --- | --- | --- | --- | --- | --- | --- |
| 29 | 1.4 | **T2.4 Business Process (Re-) engineering** |  | 131d? | 2001-10-01 | 2002-03-30 |  |  |  | 1d |  |
| 30 | 1.4.1 | T2.4.1 Specification of selected business processes |  | 131d? | 2001-10-01 | 2002-03-30 |  |  |  | 1d | finish no earlier than 2002-03-30 |
| 31 | 1.4.2 | T2.4.2 Traduction of selected business processes in UML |  | 131d? | 2001-10-01 | 2002-03-30 |  |  |  | 1d | finish no earlier than 2002-03-30 |
| 32 | 1.5 | T2.5 Market Preparation |  | 131d? | 2001-10-01 | 2002-03-30 |  |  |  | 1d | finish no earlier than 2002-03-30 |
| 34 | 2 | M2-Milestone 2 | milestone | 1d | 2002-04-01 | 2002-04-01 | 2001-07-02 | 2001-07-02 | 1d | 0d | start no earlier than 2002-04-01 |
